# แผนงานก่อสร้าง Civil

Schedule from MS Project, 2025-03-03 to 2025-03-17.

## Calendars

- Standard: Mon-Sun 08:00-12:00, 13:00-17:00.

## Schedule

| ID | WBS | Task | Duration | Start | Finish | Predecessors | Total slack | Constraint |
| --- | --- | --- | --- | --- | --- | --- | --- | --- |
| 1 | 1 | **ระบบรายน้ำและถนนรอบอาคารสำนักงาน 4 ชั้น GIE** | 15d | 2025-03-03 | 2025-03-17 |  |  |  |
| 2 | 1.1 | **1. งานระบบรายน้ำเสีย จากอาคาร** | 4d | 2025-03-03 | 2025-03-06 |  |  |  |
| 3 | 1.1.1 | **1.1 งานจักรกลหนัก และงานขุดเปิดวางระบบระบายน้ำ** | 4d | 2025-03-03 | 2025-03-06 |  |  |  |
| 4 | 1.1.1.1 | **Survey ตำแหน่ง & ระดับขุด** | 2d | 2025-03-03 | 2025-03-04 |  | 13d |  |
| 5 | 1.1.1.1.1 | งานให้ตำแหน่ง | 1d | 2025-03-03 | 2025-03-03 |  | 14d | start no earlier than 2024-07-18 |
| 6 | 1.1.1.1.2 | งานให้ระดับขุด | 2d | 2025-03-03 | 2025-03-04 |  | 13d |  |
| 7 | 1.1.1.2 | **งานระบบระบายน้ำ STRUCTURE** | 4d | 2025-03-03 | 2025-03-06 |  |  |  |
| 8 | 1.1.1.2.1 | งานขุดดินเพื่อเปิดงานวาง Manholer&ท่อ คสล (ความลึก 1.50-2.00 เมตร) | 2d | 2025-03-03 | 2025-03-04 |  | 13d |  |
| 9 | 1.1.1.2.2 | คอนกรีตหยาบ fc'=140 ksc. (ความหนา 0.05 m.) | 2d | 2025-03-03 | 2025-03-04 |  | 0d |  |
| 10 | 1.1.1.2.3 | บ่อพักน้ำ คสล.ขนาด 0.80x0.80m (พร้อมต่อปากบ่อและปิดฝาให้เรียบร้อย) | 1d | 2025-03-05 | 2025-03-05 | 9 | 0d |  |
| 11 | 1.1.1.2.4 | ท่อระบายน้ำ คสล. ขนาด 0.40 x1.00m (เกร๊ตด้าน นอกเกินครั้งใบ) | 2d | 2025-03-05 | 2025-03-06 | 9 | 11d |  |
| 12 | 1.1.1.2.5 | งานต่อท่อ PVC จากระบบระบายน้ำจากตัวอาคารเข้าบ่อพักน้ำ Manholer | 1d | 2025-03-05 | 2025-03-05 | 9 | 12d |  |
| 13 | 1.1.1.2.6 | ปรับเกลี่ยกองดิน (หลังวางท่อและเกร๊ตท่อในและนอก แล้วเสร็จทั้งหมด) | 1d | 2025-03-06 | 2025-03-06 | 10 | 0d |  |
| 14 | 1.2 | **2. งานถนน คสล. ความหนา 15 cm. จำนวน 895 ตารางเมตร** | 11d | 2025-03-07 | 2025-03-17 | 13 |  |  |
| 15 | 1.2.1 | **2.1 งานจักรกลหนัก และงงานถนน คสล. จำนวน 895 ตารางเมตร** | 11d | 2025-03-07 | 2025-03-17 |  |  |  |
| 16 | 1.2.1.1 | **Survey ตำแหน่ง & ระดับขุด** | 7d | 2025-03-07 | 2025-03-13 |  | 4d |  |
| 17 | 1.2.1.1.1 | งานให้ตำแหน่ง | 4d | 2025-03-07 | 2025-03-10 |  | 7d | start no earlier than 2024-07-18 |
| 18 | 1.2.1.1.2 | งานให้ระดับเทคอนกรีต | 7d | 2025-03-07 | 2025-03-13 |  | 4d |  |
| 19 | 1.2.1.2 | **งานเทคอนกรีตถนน STRUCTURE** | 11d | 2025-03-07 | 2025-03-17 |  |  |  |
| 20 | 1.2.1.2.1 | งานจัดเตรียม วัสดุอุปกรณ์ (ความพร้อม เหล็ก/แบบ/เครื่องมือ) | 3d | 2025-03-07 | 2025-03-09 |  | 8d |  |
| 21 | 1.2.1.2.2 | ปรับพื้นที่ตั้งแบบลงทรายบดอัด | 5d | 2025-03-07 | 2025-03-11 |  | 6d |  |
| 22 | 1.2.1.2.3 | งานเทคอนกรีตถนน พร้อมเก็บผิว | 9d | 2025-03-08 | 2025-03-16 |  | 1d | start no earlier than 2025-03-08 |
| 23 | 1.2.1.2.4 | งานตัด Joint หยอดยาง | 7d | 2025-03-11 | 2025-03-17 |  | 0d | start no earlier than 2025-03-11 |
